# Védőfal3

Schedule from MS Project, 2007-10-01 to 2007-11-13, costs in Ft.
WSH Kft

## Calendars

- Standard: Mon-Fri 08:00-12:00, 13:00-17:00; Sat-Sun off.
- Utókezelés: Mon-Sun 08:00-09:00.

## Resources

| Resource | Rate |
| --- | --- |
| Segédmunkás | 1000 |
| Kőműves | 1500 |
| Zsaluanyag |  |
| FS Bt. | 2500 |
| Kertész | 1100 |
| Kerítéselemek |  |

## Schedule

| ID | WBS | Task | Type | Duration | Start | Finish | Predecessors | Total slack | Free slack | Constraint | Deadline | Resources | Work | Cost |
| --- | --- | --- | --- | --- | --- | --- | --- | --- | --- | --- | --- | --- | --- | --- |
| 1 | 1 | **Raktárak korszerűsítése** |  | 26d | 2007-10-01 | 2007-11-05 |  | -1d | 0d |  |  |  | 1656h | 2,164,000 |
| 2 | 1.1 | Keret1 | milestone | 0d | 2007-10-01 | 2007-10-01 |  | 32d |  |  |  |  |  |  |
| 3 | 1.2 | Tereprendezés |  | 6d | 2007-10-01 | 2007-10-08 |  | -1d | 0d |  |  | Segédmunkás [600%] | 288h | 288,000 |
| 4 | 1.3 | Tereprendezés kész | milestone | 0d | 2007-10-08 | 2007-10-08 | 3 | -1d | 0d |  | 2007-10-05 |  |  |  |
| 5 | 1.4 | Szükséges anyagok és eszközök kiszállítása |  | 1d | 2007-10-09 | 2007-10-09 | 4 | 3d | 0d |  |  | Segédmunkás [200%] | 16h | 16,000 |
| 6 | 1.5 | Felvonulási épület felállítása |  | 2d | 2007-10-10 | 2007-10-11 | 5 | 21d | 0d |  |  | Segédmunkás [200%]; Kőműves | 48h | 56,000 |
| 7 | 1.6 | .Felvonulási épület elkészült | milestone | 0d | 2007-10-11 | 2007-10-11 | 6 | 23d |  |  |  |  |  |  |
| 8 | 1.7 | A kiürített raktár átvétele | milestone | 0d | 2007-10-02 | 2007-10-02 |  | 8d | 5d | finish no earlier than 2007-10-02 |  |  |  |  |
| 9 | 1.8 | Falak megerősítése |  | 4d | 2007-10-10 | 2007-10-15 | 8, 5 | 11d | 0d |  |  | Kőműves [200%]; Segédmunkás [600%] | 256h | 288,000 |
| 10 | 1.9 | -S1 |  | 1d | 2007-10-16 | 2007-10-16 | 9 | 14d | 0d |  |  |  |  |  |
| 11 | 1.10 | Nyílászárók cseréje |  | 3d | 2007-10-12 | 2007-10-16 | 9SS+1d, 10FF | 14d | 11d |  |  | Kőműves; Segédmunkás [200%] | 72h | 84,000 |
| 12 | 1.11 | Belső terek szabvány szerinti átalakítása |  | 12d | 2007-10-10 | 2007-10-25 | 8, 5 | 3d | 0d |  |  | Kőműves [200%]; Segédmunkás [600%] | 768h | 864,000 |
| 13 | 1.12 | Tűzoltórendszer átalakítása |  | 4d | 2007-10-26 | 2007-10-31 | 9, 12 | 3d | 0d |  |  | FS Bt. [500%] | 160h | 400,000 |
| 14 | 1.13 | Új biztonsági rendszer kiépítése |  | 3d | 2007-11-01 | 2007-11-05 | 11, 13 | 3d | 0d |  |  | FS Bt. [200%] | 48h | 168,000 |
| 15 | 1.14 | Korszerűsítés kész | milestone | 0d | 2007-11-05 | 2007-11-05 | 14 | 3d |  |  | 2007-11-08 |  |  |  |
| 16 | 1.15 | .Kiszámlázhatók a korszerűsítési munkálatok | milestone | 0d | 2007-11-05 | 2007-11-05 | 14 | 6d |  |  |  |  |  |  |
| 17 | 2 | Döntés a védőfalépítés megkezdéséről | milestone | 0d | 2007-10-11 | 2007-10-11 |  | 0d |  | finish no earlier than 2007-10-11 |  |  |  |  |
| 18 | 3 | **Védőfal elkészítése** |  | 21d | 2007-10-11 | 2007-11-11 | 17 | 0d |  |  |  |  | 600h | 668,000 |
| 19 | 3.1 | Keret2 | milestone | 0d | 2007-10-11 | 2007-10-11 |  | 23d |  |  |  |  |  |  |
| 20 | 3.2 | Szükséges anyagok és eszközök kiszállítása |  | 1d | 2007-10-12 | 2007-10-12 |  | 0d |  |  |  | Segédmunkás [200%] | 16h | 16,000 |
| 21 | 3.3 | Ideiglenes kerítés építése |  | 4d | 2007-10-15 | 2007-10-18 | 20, 4 | 0d |  |  |  | Segédmunkás [300%]; Kőműves | 128h | 144,000 |
| 22 | 3.4 | Régi kerítés lebontása |  | 1d | 2007-10-19 | 2007-10-19 | 21 | 0d |  |  |  | Segédmunkás [200%] | 16h | 16,000 |
| 23 | 3.5 | Alapásás |  | 1d | 2007-10-22 | 2007-10-22 | 22 | 0d |  |  |  | Segédmunkás [500%] | 40h | 40,000 |
| 24 | 3.6 | Vasszerelés |  | 2d | 2007-10-23 | 2007-10-24 | 23 | 0d |  |  |  | Segédmunkás [300%]; Kőműves | 64h | 72,000 |
| 25 | 3.7 | Ellenőrzés | milestone | 0d | 2007-10-24 | 2007-10-24 | 24 | 0d |  | finish no earlier than 2007-10-24 | 2007-10-24 |  |  |  |
| 26 | 3.8 | Zsaluzás |  | 5d | 2007-10-25 | 2007-10-31 | 25 | 0d |  |  |  | Kőműves; Segédmunkás [300%] | 160h | 180,000 |

| ID | WBS | Task | Type | Duration | Start | Finish | Predecessors | Total slack | Free slack | Constraint | Deadline | Calendar | Resources | Work | Cost |
| --- | --- | --- | --- | --- | --- | --- | --- | --- | --- | --- | --- | --- | --- | --- | --- |
| 27 | 3.9 | **:Betonozás** |  | 5d | 2007-10-25 | 2007-11-01 |  | 0d |  |  |  |  | Kőműves; Segédmunkás [300%] | 160h | 180,000 |
| 28 | 3.9.1 | Betonozás kezdete | milestone | 0d | 2007-10-25 | 2007-10-25 | 26SS+1d | 5d |  |  |  |  |  |  |  |
| 29 | 3.9.2 | Betonozás vége | milestone | 0d | 2007-11-01 | 2007-11-01 | 26FS+1d | 0d |  |  |  |  |  |  |  |
| 30 | 3.10 | **Utókezelés** |  | 1.25d | 2007-11-02 | 2007-11-11 |  | 0.25d |  |  |  | Utókezelés |  |  |  |
| 31 | 3.10.1 | Utókezelés 1 |  | 1h | 2007-11-02 | 2007-11-02 | 27 | 0.25d |  |  |  | Utókezelés |  |  |  |
| 32 | 3.10.2 | Utókezelés 2 |  | 1h | 2007-11-03 | 2007-11-03 | 31 | 0.25d | 0d |  |  | Utókezelés |  |  |  |
| 33 | 3.10.3 | Utókezelés 3 |  | 1h | 2007-11-04 | 2007-11-04 | 32 | 0.25d | 0d |  |  | Utókezelés |  |  |  |
| 34 | 3.10.4 | Utókezelés 4 |  | 1h | 2007-11-05 | 2007-11-05 | 33 | 0.25d |  |  |  | Utókezelés |  |  |  |
| 35 | 3.10.5 | Utókezelés 5 |  | 1h | 2007-11-06 | 2007-11-06 | 34 | 0.25d |  |  |  | Utókezelés |  |  |  |
| 36 | 3.10.6 | Utókezelés 6 |  | 1h | 2007-11-07 | 2007-11-07 | 35 | 0.25d |  |  |  | Utókezelés |  |  |  |
| 37 | 3.10.7 | Utókezelés 7 |  | 1h | 2007-11-08 | 2007-11-08 | 36 | 0.25d |  |  |  | Utókezelés |  |  |  |
| 38 | 3.10.8 | Utókezelés 8 |  | 1h | 2007-11-09 | 2007-11-09 | 37 | 0.25d |  |  |  | Utókezelés |  |  |  |
| 39 | 3.10.9 | Utókezelés 9 |  | 1h | 2007-11-10 | 2007-11-10 | 38 | 0.25d | 0d |  |  | Utókezelés |  |  |  |
| 40 | 3.10.10 | Utókezelés 10 |  | 1h | 2007-11-11 | 2007-11-11 | 39 | 0.25d |  |  |  | Utókezelés |  |  |  |
| 41 | 3.11 | ! Kizsaluzhatósági idő |  | 3ed | 2007-11-01 | 2007-11-04 | 27 | 1.88d |  |  |  |  |  |  |  |
| 42 | 3.12 | Kizsaluzás |  | 1d | 2007-11-05 | 2007-11-05 | 41 | 0d |  |  |  |  | Segédmunkás; Kőműves | 16h | 20,000 |
| 43 | 3.13 | Védőkerítés kész | milestone | 0d | 2007-11-05 | 2007-11-05 | 42 | 0d |  |  | 2007-11-16 |  |  |  |  |
| 44 | 3.14 | .Kiszámlázhatóak a védőfallal kapcsolatos munkálatok | milestone | 0d | 2007-11-05 | 2007-11-05 | 42 | 6d |  |  |  |  |  |  |  |
| 45 | 4 | **Utómunkálatok** |  | 9d | 2007-11-01 | 2007-11-13 |  | 0d |  |  |  |  |  | 320h | 323,200 |
| 46 | 4.1 | Keret3 | milestone | 0d | 2007-11-01 | 2007-11-01 |  | 9d |  | start no earlier than 2007-11-01 |  |  |  |  |  |
| 47 | 4.2 | Felvonulási épület lebontása |  | 2d | 2007-11-07 | 2007-11-08 | 6, 50FF | 3d |  |  |  |  | Segédmunkás [300%] | 48h | 48,000 |
| 48 | 4.3 | Építkezési törmelék elszállítása |  | 2d | 2007-11-06 | 2007-11-07 | 43 | 0d |  |  |  |  | Segédmunkás [400%] | 64h | 64,000 |
| 49 | 4.4 | Ideiglenes kerítés elbontása |  | 1d | 2007-11-08 | 2007-11-08 | 48 | 3d | 0d |  |  |  | Segédmunkás [200%] | 16h | 16,000 |
| 50 | 4.5 | Átadás | milestone | 0d | 2007-11-08 | 2007-11-08 | 15, 49 | 3d | 0d |  | 2007-11-23 |  |  |  |  |
| 51 | 4.6 | Tereprendezés |  | 2d | 2007-11-08 | 2007-11-09 | 48 | 0d |  |  |  |  | Segédmunkás [600%] | 96h | 96,000 |
| 52 | 4.7 | Fák ültetése |  | 2d | 2007-11-12 | 2007-11-13 | 51 | 0d |  |  |  |  | Kertész [200%]; Segédmunkás [400%] | 96h | 99,200 |

| ID | WBS | Task | Type | Duration | Start | Finish | Predecessors | Total slack | Resources | Work |
| --- | --- | --- | --- | --- | --- | --- | --- | --- | --- | --- |
| 53 | 5 | **Erőforrás-foglalásitevékenységek** |  | 19d | 2007-10-15 | 2007-11-08 |  | 3d |  | 216h |
| 54 | 5.1 | **:Zsaluanyagok foglalása** |  | 8d | 2007-10-25 | 2007-11-05 |  | 6d | Zsaluanyag | 64h |
| 55 | 5.1.1 | FK | milestone | 0d | 2007-10-25 | 2007-10-25 | 26SS | 14d |  |  |
| 56 | 5.1.2 | FV | milestone | 0d | 2007-11-05 | 2007-11-05 | 42 | 6d |  |  |
| 57 | 5.2 | **:Ideiglenes kerítéselemek foglalása** |  | 19d | 2007-10-15 | 2007-11-08 |  | 3d | Kerítéselemek | 152h |
| 58 | 5.2.1 | FK | milestone | 0d | 2007-10-15 | 2007-10-15 | 21SS | 22d |  |  |
| 59 | 5.2.2 | FV | milestone | 0d | 2007-11-08 | 2007-11-08 | 49 | 3d |  |  |
