# Védőfal4

Schedule from MS Project, 2007-10-01 to 2007-11-15, costs in Ft.
WSH Kft

## Calendars

- Standard: Mon-Fri 08:00-12:00, 13:00-17:00; Sat-Sun off.
- Utókezelés: Mon-Sun 08:00-09:00.

## Resources

| Resource | Rate |
| --- | --- |
| Segédmunkás | 1000 |
| Kőműves | 1500 |
| Zsaluanyag |  |
| FS Bt. | 2500 |
| Kertész | 1100 |
| Kerítéselemek |  |

## Schedule

| ID | WBS | Task | Type | Duration | Start | Finish | Predecessors | Total slack | Free slack | Constraint | Deadline | Resources | Work | Cost |
| --- | --- | --- | --- | --- | --- | --- | --- | --- | --- | --- | --- | --- | --- | --- |
| 1 | 1 | **Raktárak korszerűsítése** |  | 26d | 2007-10-01 | 2007-11-05 |  | -1d | 0d |  |  |  | 1656h | 2,164,000 |
| 2 | 1.1 | Keret1 | milestone | 0d | 2007-10-01 | 2007-10-01 |  | 34d |  |  |  |  |  |  |
| 3 | 1.2 | Tereprendezés |  | 6d | 2007-10-01 | 2007-10-08 |  | -1d | 0d |  |  | Segédmunkás [600%] | 288h | 288,000 |
| 4 | 1.3 | Tereprendezés kész | milestone | 0d | 2007-10-08 | 2007-10-08 | 3 | -1d | 0d |  | 2007-10-05 |  |  |  |
| 5 | 1.4 | Számla1 | milestone | 0d | 2007-10-11 | 2007-10-11 |  | 25d |  | finish no earlier than 2007-10-11 |  |  |  |  |
| 6 | 1.5 | Szükséges anyagok és eszközök kiszállítása |  | 1d | 2007-10-09 | 2007-10-09 | 4 | 3d | 0d |  |  | Segédmunkás [200%] | 16h | 16,000 |
| 7 | 1.6 | Felvonulási épület felállítása |  | 2d | 2007-10-10 | 2007-10-11 | 6 | 23d | 0d |  |  | Segédmunkás [200%]; Kőműves | 48h | 56,000 |
| 8 | 1.7 | .Felvonulási épület elkészült | milestone | 0d | 2007-10-11 | 2007-10-11 | 7 | 25d |  |  |  |  |  |  |
| 9 | 1.8 | Számla2 | milestone | 0d | 2007-10-15 | 2007-10-15 |  | 23d |  | finish no earlier than 2007-10-15 |  |  |  |  |
| 10 | 1.9 | A kiürített raktár átvétele | milestone | 0d | 2007-10-02 | 2007-10-02 |  | 8d | 5d | finish no earlier than 2007-10-02 |  |  |  |  |
| 11 | 1.10 | Falak megerősítése |  | 4d | 2007-10-10 | 2007-10-15 | 10, 6 | 11d | 0d |  |  | Kőműves [200%]; Segédmunkás [600%] | 256h | 288,000 |
| 12 | 1.11 | -S1 |  | 1d | 2007-10-16 | 2007-10-16 | 11 | 14d | 0d |  |  |  |  |  |
| 13 | 1.12 | Nyílászárók cseréje |  | 3d | 2007-10-12 | 2007-10-16 | 11SS+1d, 12FF | 14d | 11d |  |  | Kőműves; Segédmunkás [200%] | 72h | 84,000 |
| 14 | 1.13 | Belső terek szabvány szerinti átalakítása |  | 12d | 2007-10-10 | 2007-10-25 | 10, 6 | 3d | 0d |  |  | Kőműves [200%]; Segédmunkás [600%] | 768h | 864,000 |
| 15 | 1.14 | Tűzoltórendszer átalakítása |  | 4d | 2007-10-26 | 2007-10-31 | 11, 14 | 3d | 0d |  |  | FS Bt. [500%] | 160h | 400,000 |
| 16 | 1.15 | Új biztonsági rendszer kiépítése |  | 3d | 2007-11-01 | 2007-11-05 | 13, 15 | 3d | 0d |  |  | FS Bt. [200%] | 48h | 168,000 |
| 17 | 1.16 | Korszerűsítés kész | milestone | 0d | 2007-11-05 | 2007-11-05 | 16 | 3d |  |  | 2007-11-08 |  |  |  |
| 18 | 1.17 | .Kiszámlázhatók a korszerűsítési munkálatok | milestone | 0d | 2007-11-05 | 2007-11-05 | 16 | 8d |  |  |  |  |  |  |
| 19 | 2 | Döntés a védőfalépítés megkezdéséről | milestone | 0d | 2007-10-11 | 2007-10-11 |  | 0d |  | finish no earlier than 2007-10-11 |  |  |  |  |
| 20 | 3 | **Védőfal elkészítése** |  | 21d | 2007-10-11 | 2007-11-11 | 19 | 0d |  |  |  |  | 600h | 668,000 |
| 21 | 3.1 | Keret2 | milestone | 0d | 2007-10-11 | 2007-10-11 |  | 25d |  |  |  |  |  |  |
| 22 | 3.2 | Szükséges anyagok és eszközök kiszállítása |  | 1d | 2007-10-12 | 2007-10-12 |  | 0d |  |  |  | Segédmunkás [200%] | 16h | 16,000 |
| 23 | 3.3 | Ideiglenes kerítés építése |  | 4d | 2007-10-15 | 2007-10-18 | 22, 4 | 0d |  |  |  | Segédmunkás [300%]; Kőműves | 128h | 144,000 |
| 24 | 3.4 | Régi kerítés lebontása |  | 1d | 2007-10-19 | 2007-10-19 | 23 | 0d |  |  |  | Segédmunkás [200%] | 16h | 16,000 |
| 25 | 3.5 | Alapásás |  | 1d | 2007-10-22 | 2007-10-22 | 24 | 0d |  |  |  | Segédmunkás [500%] | 40h | 40,000 |
| 26 | 3.6 | Vasszerelés |  | 2d | 2007-10-23 | 2007-10-24 | 25 | 0d |  |  |  | Segédmunkás [300%]; Kőműves | 64h | 72,000 |
| 27 | 3.7 | Ellenőrzés | milestone | 0d | 2007-10-24 | 2007-10-24 | 26 | 0d |  | finish no earlier than 2007-10-24 | 2007-10-24 |  |  |  |
| 28 | 3.8 | Számla3 | milestone | 0d | 2007-10-29 | 2007-10-29 |  | 13d |  | finish no earlier than 2007-10-29 |  |  |  |  |
| 29 | 3.9 | Zsaluzás |  | 5d | 2007-10-25 | 2007-10-31 | 27 | 1d | 0d |  |  | Kőműves; Segédmunkás [300%] | 160h | 180,000 |

| ID | WBS | Task | Type | Duration | Start | Finish | Predecessors | Total slack | Free slack | Constraint | Deadline | Calendar | Resources | Work | Cost |
| --- | --- | --- | --- | --- | --- | --- | --- | --- | --- | --- | --- | --- | --- | --- | --- |
| 30 | 3.10 | **:Betonozás** |  | 5d | 2007-10-25 | 2007-11-01 |  | 1d | 0d |  |  |  | Kőműves; Segédmunkás [300%] | 160h | 180,000 |
| 31 | 3.10.1 | Betonozás kezdete | milestone | 0d | 2007-10-25 | 2007-10-25 | 29SS+1d | 6d |  |  |  |  |  |  |  |
| 32 | 3.10.2 | Betonozás vége | milestone | 0d | 2007-11-01 | 2007-11-01 | 29FS+1d | 1d |  |  |  |  |  |  |  |
| 33 | 3.11 | **Utókezelés** |  | 1.25d | 2007-11-02 | 2007-11-11 |  | 0.5d |  |  |  | Utókezelés |  |  |  |
| 34 | 3.11.1 | Utókezelés 1 |  | 1h | 2007-11-02 | 2007-11-02 | 30 | 0.5d | 0.88d |  |  | Utókezelés |  |  |  |
| 35 | 3.11.2 | Utókezelés 2 |  | 1h | 2007-11-03 | 2007-11-03 | 34 | 0.5d | 0d |  |  | Utókezelés |  |  |  |
| 36 | 3.11.3 | Utókezelés 3 |  | 1h | 2007-11-04 | 2007-11-04 | 35 | 0.5d | 0d |  |  | Utókezelés |  |  |  |
| 37 | 3.11.4 | Utókezelés 4 |  | 1h | 2007-11-05 | 2007-11-05 | 36 | 0.5d | 0.88d |  |  | Utókezelés |  |  |  |
| 38 | 3.11.5 | Utókezelés 5 |  | 1h | 2007-11-06 | 2007-11-06 | 37 | 0.5d | 0.88d |  |  | Utókezelés |  |  |  |
| 39 | 3.11.6 | Utókezelés 6 |  | 1h | 2007-11-07 | 2007-11-07 | 38 | 0.5d | 0.88d |  |  | Utókezelés |  |  |  |
| 40 | 3.11.7 | Utókezelés 7 |  | 1h | 2007-11-08 | 2007-11-08 | 39 | 0.5d | 0.88d |  |  | Utókezelés |  |  |  |
| 41 | 3.11.8 | Utókezelés 8 |  | 1h | 2007-11-09 | 2007-11-09 | 40 | 0.5d | 0.88d |  |  | Utókezelés |  |  |  |
| 42 | 3.11.9 | Utókezelés 9 |  | 1h | 2007-11-10 | 2007-11-10 | 41 | 0.5d | 0d |  |  | Utókezelés |  |  |  |
| 43 | 3.11.10 | Utókezelés 10 |  | 1h | 2007-11-11 | 2007-11-11 | 42 | 0.5d |  |  |  | Utókezelés |  |  |  |
| 44 | 3.12 | ! Kizsaluzhatósági idő |  | 3ed | 2007-11-01 | 2007-11-04 | 30 | 7.88d | 1.88d |  |  |  |  |  |  |
| 45 | 3.13 | Kizsaluzás |  | 1d | 2007-11-05 | 2007-11-05 | 44 | 2d | 0d |  |  |  | Segédmunkás; Kőműves | 16h | 20,000 |
| 46 | 3.14 | Védőkerítés kész | milestone | 0d | 2007-11-05 | 2007-11-05 | 45 | 2d | 0d |  | 2007-11-16 |  |  |  |  |
| 47 | 3.15 | .Kiszámlázhatóak a védőfallal kapcsolatos munkálatok | milestone | 0d | 2007-11-05 | 2007-11-05 | 45 | 8d |  |  |  |  |  |  |  |
| 48 | 3.16 | Számla4 | milestone | 0d | 2007-11-06 | 2007-11-06 |  | 8d |  | start no earlier than 2007-11-06 |  |  |  |  |  |
| 49 | 4 | **Utómunkálatok** |  | 11d | 2007-11-01 | 2007-11-15 |  | 0d |  |  |  |  |  | 320h | 323,200 |
| 50 | 4.1 | Keret3 | milestone | 0d | 2007-11-01 | 2007-11-01 |  | 11d |  | start no earlier than 2007-11-01 |  |  |  |  |  |
| 51 | 4.2 | Felvonulási épület lebontása |  | 2d | 2007-11-07 | 2007-11-08 | 7, 55FF | 5d |  |  |  |  | Segédmunkás [300%] | 48h | 48,000 |
| 52 | 4.3 | Építkezési törmelék elszállítása |  | 2d | 2007-11-06 | 2007-11-07 | 46 | 2d | 0d |  |  |  | Segédmunkás [400%] | 64h | 64,000 |
| 53 | 4.4 | Számla5 | milestone | 0d | 2007-11-12 | 2007-11-12 |  | 3d |  | finish no earlier than 2007-11-12 |  |  |  |  |  |
| 54 | 4.5 | Ideiglenes kerítés elbontása |  | 1d | 2007-11-08 | 2007-11-08 | 52 | 5d | 0d |  |  |  | Segédmunkás [200%] | 16h | 16,000 |
| 55 | 4.6 | Átadás | milestone | 0d | 2007-11-08 | 2007-11-08 | 17, 54 | 5d | 0d |  | 2007-11-23 |  |  |  |  |
| 56 | 4.7 | Tereprendezés |  | 2d | 2007-11-08 | 2007-11-09 | 52 | 2d | 0d |  |  |  | Segédmunkás [600%] | 96h | 96,000 |
| 57 | 4.8 | Fák ültetése |  | 2d | 2007-11-12 | 2007-11-13 | 56 | 2d |  |  |  |  | Kertész [200%]; Segédmunkás [400%] | 96h | 99,200 |
| 58 | 4.9 | Számla6 | milestone | 0d | 2007-11-15 | 2007-11-15 |  | 0d |  | finish no earlier than 2007-11-15 |  |  |  |  |  |

| ID | WBS | Task | Type | Duration | Start | Finish | Predecessors | Total slack | Resources | Work |
| --- | --- | --- | --- | --- | --- | --- | --- | --- | --- | --- |
| 59 | 5 | **Erőforrás-foglalásitevékenységek** |  | 19d | 2007-10-15 | 2007-11-08 |  | 5d |  | 216h |
| 60 | 5.1 | **:Zsaluanyagok foglalása** |  | 8d | 2007-10-25 | 2007-11-05 |  | 8d | Zsaluanyag | 64h |
| 61 | 5.1.1 | FK | milestone | 0d | 2007-10-25 | 2007-10-25 | 29SS | 16d |  |  |
| 62 | 5.1.2 | FV | milestone | 0d | 2007-11-05 | 2007-11-05 | 45 | 8d |  |  |
| 63 | 5.2 | **:Ideiglenes kerítéselemek foglalása** |  | 19d | 2007-10-15 | 2007-11-08 |  | 5d | Kerítéselemek | 152h |
| 64 | 5.2.1 | FK | milestone | 0d | 2007-10-15 | 2007-10-15 | 23SS | 24d |  |  |
| 65 | 5.2.2 | FV | milestone | 0d | 2007-11-08 | 2007-11-08 | 54 | 5d |  |  |
